# CPOE Project Initiation Plan

Schedule from MS Project, 2009-04-01 to 2010-06-02, A marks actual dates.
CareTech Solutions

## Calendars

- Standard: Mon-Fri 08:00-12:00, 13:00-17:00; Sat-Sun off.

## Resources

| Resource |
| --- |
| Core Team |
| I.S. Mgr of Clin Apps |
| Clinical Informatics (RN) |
| Project Manager |
| CMIO |
| Executive Team |
| CIO |
| I.S. Manager |
| Director of Billing & Finance |
| Director of Technology |
| CPOE Vendor |
| CFO |
| Process Engineer |
| Consultant |
| Tech Services |
| Marketing |
| Nursing |
| Departments |
| physicians |

## Schedule

| ID | WBS | Task | Type | Duration | Start | Finish | Predecessors | Complete | Remaining | Total slack | Free slack | Constraint | Resources | Work | Actual work |
| --- | --- | --- | --- | --- | --- | --- | --- | --- | --- | --- | --- | --- | --- | --- | --- |
| 1 | 1 | **Sample CPOE Project Initiation Plan (Just Project Initiation activities - not the implementation)** |  | 306d? | 2009-04-01 A | 2010-06-02 |  | 29% | 218.59d? | 0d |  |  |  | 10874h | 2305.17h |
| 2 | 1.1 | **Pre Project Work** |  | 237d | 2009-04-01 A | 2010-02-25 |  | 95% | 11.07d | 69d |  |  |  | 1344h | 1224h |
| 3 | 1.1.1 | CPOE Readiness Assessment |  | 70d | 2009-04-01 A | 2009-07-07 A |  | 100% |  |  |  | start no earlier than 2009-04-01 | Consultant | 560h | 560h |
| 4 | 1.1.2 | CPOE System overview - system demo |  | 1d | 2010-01-22 A | 2010-01-22 A |  | 100% |  |  |  | start no earlier than 2010-01-22 | CPOE Vendor; Core Team | 16h | 16h |
| 5 | 1.1.3 | Site Visit Review COE in live setting |  | 1d | 2010-02-18 A | 2010-02-18 A |  | 100% |  |  |  | start no earlier than 2010-02-18 | Core Team | 8h | 8h |
| 6 | 1.1.4 | **Assess Technical Environment** |  | 5d | 2010-01-04 A | 2010-01-08 A |  | 100% |  |  |  |  |  | 480h | 480h |
| 7 | 1.1.4.1 | Identify Peripheral Device Needs |  | 1w | 2010-01-04 A | 2010-01-08 A |  | 100% |  |  |  | start no earlier than 2010-01-04 | CIO; Tech Services; CPOE Vendor | 120h | 120h |
| 8 | 1.1.4.2 | Identify Storage and Server Needs |  | 1w | 2010-01-04 A | 2010-01-08 A |  | 100% |  |  |  | start no earlier than 2010-01-04 | CIO; Tech Services; CPOE Vendor | 120h | 120h |
| 9 | 1.1.4.3 | Identify Networking Needs |  | 1w | 2010-01-04 A | 2010-01-08 A |  | 100% |  |  |  | start no earlier than 2010-01-04 | Director of Technology; Tech Services; CPOE Vendor | 120h | 120h |
| 10 | 1.1.4.4 | Identify IT dependencies - upgrades |  | 1w | 2010-01-04 A | 2010-01-08 A |  | 100% |  |  |  | start no earlier than 2010-01-04 | CPOE Vendor; I.S. Mgr of Clin Apps; CIO | 120h | 120h |
| 11 | 1.1.5 | Identify and Secure IT Resources |  | 1w | 2010-01-04 A | 2010-01-08 A |  | 100% |  |  |  | start no earlier than 2010-01-04 | CPOE Vendor; Clinical Informatics (RN); CIO | 120h | 120h |
| 12 | 1.1.6 | Identify and Secure hospital staff resources |  | 1w | 2010-02-19 | 2010-02-25 | 5 |  |  | 69d |  |  | Core Team; CIO; CFO | 120h |  |
| 13 | 1.1.7 | Identify and Secure Budget |  | 1w | 2010-01-04 A | 2010-01-08 A |  | 100% |  |  |  | start no earlier than 2010-01-04 | CIO | 40h | 40h |
| 14 | 1.2 | **Project Planning** |  | 53d | 2010-02-01 A | 2010-04-14 |  | 25% | 39.75d | 35d |  |  |  | 1264h | 224h |
| 15 | 1.2.1 | **Develop project management plan** |  | 33d | 2010-02-01 A | 2010-03-17 |  | 67% | 11d | 55d |  |  |  | 264h | 224h |
| 16 | 1.2.1.1 | Define project goals - high level |  | 3d | 2010-02-01 A | 2010-02-03 A |  | 100% |  |  |  | start no earlier than 2010-02-01 | Core Team | 24h | 24h |
| 17 | 1.2.1.2 | Define project scope |  | 3d | 2010-02-04 A | 2010-02-08 A | 16 | 100% |  |  |  |  | Project Manager; Clinical Informatics (RN); I.S. Mgr of Clin Apps | 72h | 72h |
| 18 | 1.2.1.3 | Define project organization |  | 1d | 2010-02-09 A | 2010-02-09 A | 17 | 100% |  |  |  |  | Project Manager; Clinical Informatics (RN); I.S. Mgr of Clin Apps | 24h | 24h |
| 19 | 1.2.1.4 | Define status reporting process |  | 1d | 2010-02-01 A | 2010-02-01 A | 16SS | 100% |  |  |  |  | Project Manager; Clinical Informatics (RN); I.S. Mgr of Clin Apps | 24h | 24h |
| 20 | 1.2.1.5 | Schedule core team meetings |  | 1d | 2010-02-01 A | 2010-02-01 A | 19SS | 100% |  |  |  |  | Project Manager; Clinical Informatics (RN); I.S. Mgr of Clin Apps | 24h | 24h |
| 21 | 1.2.1.6 | Define project milestones |  | 2d | 2010-02-10 A | 2010-02-11 A | 18 | 100% |  |  |  |  | Core Team | 16h | 16h |
| 22 | 1.2.1.7 | Develop project initiation plan schedule |  | 5d | 2010-03-01 A | 2010-03-05 A |  | 100% |  |  |  | start no earlier than 2010-03-01 | Project Manager | 40h | 40h |
| 23 | 1.2.1.8 | Review plan and schedule with vendor and team |  | 3d | 2010-03-08 | 2010-03-10 | 22 |  |  | 4d | 0d |  |  |  |  |
| 24 | 1.2.1.9 | Develop project plan presentation |  | 5d | 2010-03-11 | 2010-03-17 | 23 |  |  | 40d | 0d |  | Project Manager | 40h |  |
| 25 | 1.2.1.10 | Complete - sign off project management plan - scope | milestone | 0d | 2010-03-17 | 2010-03-17 | 24 |  |  | 55d |  |  | CIO; CFO; Project Manager |  |  |

| ID | WBS | Task | Duration | Start | Finish | Predecessors | Complete | Remaining | Total slack | Free slack | Constraint | Resources | Work | Actual work |
| --- | --- | --- | --- | --- | --- | --- | --- | --- | --- | --- | --- | --- | --- | --- |
| 26 | 1.2.2 | **Develop project communications plan** | 25d | 2010-03-11 | 2010-04-14 |  |  |  | 4d |  |  |  | 1000h |  |
| 27 | 1.2.2.1 | Physician engagement plan | 2w | 2010-03-11 | 2010-03-24 | 23 |  |  | 4d | 0d |  | Clinical Informatics (RN); CMIO; I.S. Mgr of Clin Apps | 240h |  |
| 28 | 1.2.2.2 | Nursing engagement plan | 2w | 2010-03-11 | 2010-03-24 | 23 |  |  | 35d | 0d |  | Clinical Informatics (RN); I.S. Mgr of Clin Apps; Director of Billing & Finance | 240h |  |
| 29 | 1.2.2.3 | Executive communications / status process | 1w | 2010-03-25 | 2010-03-31 | 24, 28 |  |  | 35d | 0d |  | Project Manager; CMIO; CIO | 120h |  |
| 30 | 1.2.2.4 | Ancillary department communication plan | 1w | 2010-03-11 | 2010-03-17 | 23 |  |  | 45d | 10d |  | Clinical Informatics (RN); CMIO; Director of Billing & Finance; I.S. Mgr of Clin Apps | 160h |  |
| 31 | 1.2.2.5 | External marketing plan | 2w | 2010-04-01 | 2010-04-14 | 29 |  |  | 35d |  |  | Clinical Informatics (RN); CIO; Marketing | 240h |  |
| 32 | 1.3 | **Procurement** | 45d | 2010-02-01 A | 2010-04-02 |  | 22% | 35.08d | 43d |  |  |  | 720h | 128h |
| 33 | 1.3.1 | Complete contract for CPOE System services & components | 4w | 2010-03-01 | 2010-03-26 |  |  |  | 43d | 0d | start no earlier than 2010-03-01 | CIO; CPOE Vendor | 320h |  |
| 34 | 1.3.2 | **Complete contract for EDIS services & components** | 20d | 2010-03-01 | 2010-03-26 |  |  |  | 48d |  |  |  | 160h |  |
| 35 | 1.3.2.1 | Secure contract staff for EDIS build | 4w | 2010-03-01 | 2010-03-26 | 33SS |  |  | 48d |  | start no earlier than 2010-03-01 | CIO | 160h |  |
| 36 | 1.3.3 | Engage CEO initiation client project manager | 1d | 2010-02-01 A | 2010-02-01 A |  | 100% |  |  |  | start no earlier than 2010-02-01 | CIO; Project Manager | 16h | 16h |
| 37 | 1.3.4 | Engage process mapping team | 1d | 2010-02-19 A | 2010-02-19 A |  | 100% |  |  |  | start no earlier than 2010-02-19 | CIO; Project Manager | 16h | 16h |
| 38 | 1.3.5 | Engage physician consultant | 1d | 2010-02-01 A | 2010-02-01 A |  | 100% |  |  |  | start no earlier than 2010-02-01 | CIO; CMIO | 16h | 16h |
| 39 | 1.3.6 | Identify and order server hardware | 1w | 2010-03-29 | 2010-04-02 | 8, 33 |  |  | 43d |  |  | Director of Technology; CIO | 80h |  |
| 40 | 1.3.7 | Identify interface needs | 2w | 2010-02-09 A | 2010-02-22 A | 17 | 100% |  |  |  |  | I.S. Manager | 80h | 80h |
| 41 | 1.3.8 | Schedule preliminary build team education | 1d | 2010-03-01 | 2010-03-01 | 33SS |  |  | 67d |  |  | CPOE Vendor; I.S. Mgr of Clin Apps; CIO; Clinical Informatics (RN) | 32h |  |
| 42 | 1.4 | **Initial Project Work** | 74d | 2010-02-19 | 2010-06-02 |  |  |  | 0d |  |  |  | 5896h |  |
| 43 | 1.4.1 | **Order Set Definitions** | 48.25d | 2010-03-08 | 2010-05-13 |  |  |  | 14.75d |  |  |  | 1800h |  |
| 44 | 1.4.1.1 | Review existing order sets | 2.25w | 2010-03-08 | 2010-03-23 |  |  |  | 14.75d | 0d | start no earlier than 2010-03-08 | Clinical Informatics (RN); I.S. Mgr of Clin Apps; CMIO; CFO | 360h |  |
| 45 | 1.4.1.2 | Engage clinical team to develop & refine order sets | 1w | 2010-03-23 | 2010-03-30 | 44 |  |  | 14.75d | 0d |  | Clinical Informatics (RN); I.S. Mgr of Clin Apps; CMIO; CIO | 160h |  |
| 46 | 1.4.1.3 | Begin - Refine Order Sets | 6.4w | 2010-03-30 | 2010-05-13 | 45 |  |  | 14.75d |  |  | Clinical Informatics (RN); I.S. Mgr of Clin Apps; CMIO; physicians; CFO | 1280h |  |
| 47 | 1.4.2 | **Downtime procedures** | 20d | 2010-03-08 | 2010-04-02 |  |  |  | 43d |  |  |  | 640h |  |
| 48 | 1.4.2.1 | Collect existing downtime procedures | 4w | 2010-03-08 | 2010-04-02 |  |  |  | 43d |  | start no earlier than 2010-03-08 | Clinical Informatics (RN); I.S. Mgr of Clin Apps; Nursing; Departments | 640h |  |
| 49 | 1.4.3 | **Define Baseline Metrics** | 20d | 2010-02-19 | 2010-03-18 |  |  |  | 54d |  |  |  | 960h |  |
| 50 | 1.4.3.1 | Define COE clinical quality metrics | 4w | 2010-02-19 | 2010-03-18 | 17, 5 |  |  | 54d |  |  | Director of Billing & Finance; Clinical Informatics (RN); CMIO | 480h |  |
| 51 | 1.4.3.2 | Define COE usage metrics | 4w | 2010-02-19 | 2010-03-18 | 17, 5 |  |  | 54d |  |  | Director of Billing & Finance; Clinical Informatics (RN); CMIO | 480h |  |

| ID | WBS | Task | Type | Duration | Start | Finish | Predecessors | Complete | Remaining | Total slack | Free slack | Constraint | Resources | Work | Actual work |
| --- | --- | --- | --- | --- | --- | --- | --- | --- | --- | --- | --- | --- | --- | --- | --- |
| 52 | 1.4.4 | **Project Communications** |  | 46d | 2010-03-25 | 2010-05-27 |  |  |  | 4d |  |  |  | 576h |  |
| 53 | 1.4.4.1 | Prepare physician presentation |  | 2w | 2010-03-25 | 2010-04-07 | 27 |  |  | 40d |  |  | Clinical Informatics (RN); CMIO | 160h |  |
| 54 | 1.4.4.2 | Prepare executive presentations |  | 2w | 2010-04-01 | 2010-04-14 | 30, 29 |  |  | 35d |  |  | Core Team | 80h |  |
| 55 | 1.4.4.3 | Schedule presentations |  | 1d | 2010-04-01 | 2010-04-01 | 27FS+1w |  |  | 4d | 0d |  | CIO; Clinical Informatics (RN) | 16h |  |
| 56 | 1.4.4.4 | Present COE Overview to Hospital Leadership |  | 8w | 2010-04-02 | 2010-05-27 | 55 |  |  | 4d |  |  | Core Team | 320h |  |
| 57 | 1.4.5 | **Process Mapping - Current State** |  | 63d | 2010-03-08 | 2010-06-02 |  |  |  | 0d |  |  |  | 1920h |  |
| 58 | 1.4.5.1 | Develop process mapping plan |  | 1w | 2010-03-08 | 2010-03-12 | 37FS+2w |  |  | 53d | 0d |  | Project Manager | 40h |  |
| 59 | 1.4.5.2 | Develop questionniare templates |  | 1w | 2010-03-08 | 2010-03-12 | 58SS |  |  | 53d | 0d |  | Project Manager; Process Engineer | 80h |  |
| 60 | 1.4.5.3 | Develop process mapping schedule |  | 1w | 2010-03-15 | 2010-03-19 | 59 |  |  | 53d |  |  | Core Team | 40h |  |
| 61 | 1.4.5.4 | Process Review Session 1 Ancillary Departments |  | 3w | 2010-03-25 | 2010-04-14 |  |  |  | 0d |  | start no earlier than 2010-03-25 | Clinical Informatics (RN); Project Manager; I.S. Mgr of Clin Apps; Departments; Process Engineer | 600h |  |
| 62 | 1.4.5.5 | Process Review Session 2 Refine ancillary flows |  | 2w | 2010-04-15 | 2010-04-28 | 61 |  |  | 0d |  |  | Clinical Informatics (RN); Project Manager; I.S. Mgr of Clin Apps; Departments; Process Engineer | 400h |  |
| 63 | 1.4.5.6 | Process Review Session 1 Nursing - Physicians |  | 2w | 2010-04-29 | 2010-05-12 | 62 |  |  | 0d |  |  | Clinical Informatics (RN); Project Manager; I.S. Mgr of Clin Apps; Nursing; Process Engineer | 400h |  |
| 64 | 1.4.5.7 | Process Review Session 2 Nursing - Physicians |  | 1w | 2010-05-13 | 2010-05-19 | 63 |  |  | 0d |  |  | Clinical Informatics (RN); Project Manager; I.S. Mgr of Clin Apps; Nursing; Process Engineer | 200h |  |
| 65 | 1.4.5.8 | Final Preparation of process flows |  | 2w | 2010-05-20 | 2010-06-02 | 64 |  |  | 0d |  |  | Project Manager; Process Engineer | 160h |  |
| 66 | 1.4.5.9 | Process Mapping Complete | milestone | 0d | 2010-06-02 | 2010-06-02 | 65 |  |  | 0d |  |  |  |  |  |
| 67 | 1.5 | **Project Management** |  | 106d | 2010-01-04 A | 2010-05-31 |  | 45% | 58.35d | 2d |  |  |  | 1650h | 729.17h |
| 68 | 1.5.1 | **Weekly Status Meetings** |  | 100.25d | 2010-01-07 A | 2010-05-27 |  | 43% | 57.29d | 4.75d |  |  | Core Team | 802h | 343.71h |
| 69 | 1.5.1.1 | Weekly Status Meetings 1 |  | 2h | 2010-01-07 A | 2010-01-07 A |  | 100% |  |  |  | start no earlier than 2010-01-07 |  |  |  |
| 70 | 1.5.1.2 | Weekly Status Meetings 2 |  | 2h | 2010-01-14 A | 2010-01-14 A |  | 100% |  |  |  | start no earlier than 2010-01-14 |  |  |  |
| 71 | 1.5.1.3 | Weekly Status Meetings 3 |  | 2h | 2010-01-21 A | 2010-01-21 A |  | 100% |  |  |  | start no earlier than 2010-01-21 |  |  |  |
| 72 | 1.5.1.4 | Weekly Status Meetings 4 |  | 2h | 2010-01-28 A | 2010-01-28 A |  | 100% |  |  |  | start no earlier than 2010-01-28 |  |  |  |
| 73 | 1.5.1.5 | Weekly Status Meetings 5 |  | 2h | 2010-02-04 A | 2010-02-04 A |  | 100% |  |  |  | start no earlier than 2010-02-04 |  |  |  |
| 74 | 1.5.1.6 | Weekly Status Meetings 6 |  | 2h | 2010-02-11 A | 2010-02-11 A |  | 100% |  |  |  | start no earlier than 2010-02-11 |  |  |  |
| 75 | 1.5.1.7 | Weekly Status Meetings 7 |  | 2h | 2010-02-18 A | 2010-02-18 A |  | 100% |  |  |  | start no earlier than 2010-02-18 |  |  |  |
| 76 | 1.5.1.8 | Weekly Status Meetings 8 |  | 2h | 2010-02-25 A | 2010-02-25 A |  | 100% |  |  |  | start no earlier than 2010-02-25 |  |  |  |
| 77 | 1.5.1.9 | Weekly Status Meetings 9 |  | 2h | 2010-03-04 A | 2010-03-04 A |  | 100% |  |  |  | start no earlier than 2010-03-04 |  |  |  |
| 78 | 1.5.1.10 | Weekly Status Meetings 10 |  | 2h | 2010-03-11 | 2010-03-11 |  |  |  | 59.75d |  | start no earlier than 2010-03-11 |  |  |  |
| 79 | 1.5.1.11 | Weekly Status Meetings 11 |  | 2h | 2010-03-18 | 2010-03-18 |  |  |  | 54.75d |  | start no earlier than 2010-03-18 |  |  |  |
| 80 | 1.5.1.12 | Weekly Status Meetings 12 |  | 2h | 2010-03-25 | 2010-03-25 |  |  |  | 49.75d |  | start no earlier than 2010-03-25 |  |  |  |
| 81 | 1.5.1.13 | Weekly Status Meetings 13 |  | 2h | 2010-04-01 | 2010-04-01 |  |  |  | 44.75d |  | start no earlier than 2010-04-01 |  |  |  |
| 82 | 1.5.1.14 | Weekly Status Meetings 14 |  | 2h | 2010-04-08 | 2010-04-08 |  |  |  | 39.75d |  | start no earlier than 2010-04-08 |  |  |  |
| 83 | 1.5.1.15 | Weekly Status Meetings 15 |  | 2h | 2010-04-15 | 2010-04-15 |  |  |  | 34.75d |  | start no earlier than 2010-04-15 |  |  |  |
| 84 | 1.5.1.16 | Weekly Status Meetings 16 |  | 2h | 2010-04-22 | 2010-04-22 |  |  |  | 29.75d |  | start no earlier than 2010-04-22 |  |  |  |
| 85 | 1.5.1.17 | Weekly Status Meetings 17 |  | 2h | 2010-04-29 | 2010-04-29 |  |  |  | 24.75d |  | start no earlier than 2010-04-29 |  |  |  |
| 86 | 1.5.1.18 | Weekly Status Meetings 18 |  | 2h | 2010-05-06 | 2010-05-06 |  |  |  | 19.75d |  | start no earlier than 2010-05-06 |  |  |  |
| 87 | 1.5.1.19 | Weekly Status Meetings 19 |  | 2h | 2010-05-13 | 2010-05-13 |  |  |  | 14.75d |  | start no earlier than 2010-05-13 |  |  |  |
| 88 | 1.5.1.20 | Weekly Status Meetings 20 |  | 2h | 2010-05-20 | 2010-05-20 |  |  |  | 9.75d |  | start no earlier than 2010-05-20 |  |  |  |
| 89 | 1.5.1.21 | Weekly Status Meetings 21 |  | 2h | 2010-05-27 | 2010-05-27 |  |  |  | 4.75d |  | start no earlier than 2010-05-27 |  |  |  |

| ID | WBS | Task | Duration | Start | Finish | Complete | Remaining | Total slack | Constraint | Resources | Work | Actual work |
| --- | --- | --- | --- | --- | --- | --- | --- | --- | --- | --- | --- | --- |
| 90 | 1.5.2 | **Meeting prep - agendas, minutes, issues** | 106d | 2010-01-04 A | 2010-05-31 | 45% | 57.82d | 2d |  | I.S. Mgr of Clin Apps | 848h | 385.45h |
| 91 | 1.5.2.1 | Meeting prep - agendas, minutes 1 | 1d | 2010-01-04 A | 2010-01-04 A | 100% |  |  | start no earlier than 2010-01-04 |  |  |  |
| 92 | 1.5.2.2 | Meeting prep - agendas, minutes 2 | 1d | 2010-01-11 A | 2010-01-11 A | 100% |  |  | start no earlier than 2010-01-11 |  |  |  |
| 93 | 1.5.2.3 | Meeting prep - agendas, minutes 3 | 1d | 2010-01-18 A | 2010-01-18 A | 100% |  |  | start no earlier than 2010-01-18 |  |  |  |
| 94 | 1.5.2.4 | Meeting prep - agendas, minutes 4 | 1d | 2010-01-25 A | 2010-01-25 A | 100% |  |  | start no earlier than 2010-01-25 |  |  |  |
| 95 | 1.5.2.5 | Meeting prep - agendas, minutes 5 | 1d | 2010-02-01 A | 2010-02-01 A | 100% |  |  | start no earlier than 2010-02-01 |  |  |  |
| 96 | 1.5.2.6 | Meeting prep - agendas, minutes 6 | 1d | 2010-02-08 A | 2010-02-08 A | 100% |  |  | start no earlier than 2010-02-08 |  |  |  |
| 97 | 1.5.2.7 | Meeting prep - agendas, minutes 7 | 1d | 2010-02-15 A | 2010-02-15 A | 100% |  |  | start no earlier than 2010-02-15 |  |  |  |
| 98 | 1.5.2.8 | Meeting prep - agendas, minutes 8 | 1d | 2010-02-22 A | 2010-02-22 A | 100% |  |  | start no earlier than 2010-02-22 |  |  |  |
| 99 | 1.5.2.9 | Meeting prep - agendas, minutes 9 | 1d | 2010-03-01 A | 2010-03-01 A | 100% |  |  | start no earlier than 2010-03-01 |  |  |  |
| 100 | 1.5.2.10 | Meeting prep - agendas, minutes 10 | 1d | 2010-03-08 A | 2010-03-08 A | 100% |  |  | start no earlier than 2010-03-08 |  |  |  |
| 101 | 1.5.2.11 | Meeting prep - agendas, minutes 11 | 1d | 2010-03-15 | 2010-03-15 |  |  | 57d | start no earlier than 2010-03-15 |  |  |  |
| 102 | 1.5.2.12 | Meeting prep - agendas, minutes 12 | 1d | 2010-03-22 | 2010-03-22 |  |  | 52d | start no earlier than 2010-03-22 |  |  |  |
| 103 | 1.5.2.13 | Meeting prep - agendas, minutes 13 | 1d | 2010-03-29 | 2010-03-29 |  |  | 47d | start no earlier than 2010-03-29 |  |  |  |
| 104 | 1.5.2.14 | Meeting prep - agendas, minutes 14 | 1d | 2010-04-05 | 2010-04-05 |  |  | 42d | start no earlier than 2010-04-05 |  |  |  |
| 105 | 1.5.2.15 | Meeting prep - agendas, minutes 15 | 1d | 2010-04-12 | 2010-04-12 |  |  | 37d | start no earlier than 2010-04-12 |  |  |  |
| 106 | 1.5.2.16 | Meeting prep - agendas, minutes 16 | 1d | 2010-04-19 | 2010-04-19 |  |  | 32d | start no earlier than 2010-04-19 |  |  |  |
| 107 | 1.5.2.17 | Meeting prep - agendas, minutes 17 | 1d | 2010-04-26 | 2010-04-26 |  |  | 27d | start no earlier than 2010-04-26 |  |  |  |
| 108 | 1.5.2.18 | Meeting prep - agendas, minutes 18 | 1d | 2010-05-03 | 2010-05-03 |  |  | 22d | start no earlier than 2010-05-03 |  |  |  |
| 109 | 1.5.2.19 | Meeting prep - agendas, minutes 19 | 1d | 2010-05-10 | 2010-05-10 |  |  | 17d | start no earlier than 2010-05-10 |  |  |  |
| 110 | 1.5.2.20 | Meeting prep - agendas, minutes 20 | 1d | 2010-05-17 | 2010-05-17 |  |  | 12d | start no earlier than 2010-05-17 |  |  |  |
| 111 | 1.5.2.21 | Meeting prep - agendas, minutes 21 | 1d | 2010-05-24 | 2010-05-24 |  |  | 7d | start no earlier than 2010-05-24 |  |  |  |
| 112 | 1.5.2.22 | Meeting prep - agendas, minutes 22 | 1d | 2010-05-31 | 2010-05-31 |  |  | 2d | start no earlier than 2010-05-31 |  |  |  |
| 113 | 1.6 | **Initial McKesson Build Activity (concurrent w initation)** | 1d? | 2010-04-01 | 2010-04-01 |  |  | 44d | start no earlier than 2010-04-01 |  |  |  |
| 114 | 1.6.1 | Review order master | 1d? | 2010-04-01 | 2010-04-01 |  |  | 44d |  |  |  |  |
| 115 | 1.6.2 | Review interfaces | 1d? | 2010-04-01 | 2010-04-01 |  |  | 44d |  |  |  |  |
| 116 | 1.6.3 | Complete CPOE System 100 CBT | 1d? | 2010-04-01 | 2010-04-01 |  |  | 44d |  |  |  |  |
| 117 | 1.6.4 | Attend CPOE System 200 Toolkit Class | 1d? | 2010-04-01 | 2010-04-01 |  |  | 44d |  |  |  |  |
| 118 | 1.6.5 | Set up communications to prepare for install | 1d? | 2010-04-01 | 2010-04-01 |  |  | 44d |  |  |  |  |
| 119 | 1.6.6 | Install serves and OS | 1d? | 2010-04-01 | 2010-04-01 |  |  | 44d |  |  |  |  |
| 120 | 1.6.7 | Load base system software | 1d? | 2010-04-01 | 2010-04-01 |  |  | 44d |  |  |  |  |
| 121 | 1.6.8 | ID peripherals for system build | 1d? | 2010-04-01 | 2010-04-01 |  |  | 44d |  |  |  |  |
| 122 | 1.6.9 | Design interfaces | 1d? | 2010-04-01 | 2010-04-01 |  |  | 44d |  |  |  |  |
| 123 | 1.6.10 | Content design session 1 | 1d? | 2010-04-01 | 2010-04-01 |  |  | 44d |  |  |  |  |
